# NEXTProject

Schedule from MS Project, 2004-02-02 to 2005-01-03, 10 hours a day, costs in \, A marks actual dates.
WinXP

## Calendars

- 표준: Mon 09:00-12:00, 13:00-20:00; Tue-Fri 08:00-12:00, 13:00-17:00; Sat-Sun off. Exceptions (off unless hours are given): 2004-12-31 13:00-19:00.

## Resources

| Resource | Group | Rate |
| --- | --- | --- |
| 이석훈 | S부 | 5000 |
| 김기영 | S부 | 4000 |
| 이가람 | S부 | 4000 |
| 전수진 | 협력시스템 | 4800 |
| 김혜영 | 협력시스템 | 3800 |
| "김혜영 |  |  |

## Schedule

| ID | WBS | Task | Type | Duration | Start | Finish | Predecessors | Complete | Remaining | Baseline start | Baseline finish | Baseline duration | Total slack | Free slack | Constraint | Resources | Work | Actual work | Cost | Baseline cost | Actual cost |
| --- | --- | --- | --- | --- | --- | --- | --- | --- | --- | --- | --- | --- | --- | --- | --- | --- | --- | --- | --- | --- | --- |
| 1 | 1 | 계약 | milestone | 0d | 2004-02-02 | 2004-02-02 |  |  |  | 2004-02-02 | 2004-02-02 | 0d | 202.4d |  | start no earlier than 2004-02-02 |  |  |  |  |  |  |
| 2 | 2 | **요구사항 분석** |  | 12.4d | 2004-02-02 A | 2004-02-20 A |  | 100% |  | 2004-02-02 | 2004-02-20 | 12.4d |  |  |  |  | 160h | 160h | 614,000 | 614,000 | 614,000 |
| 3 | 2.1 | 요구사항 분석 |  | 10d | 2004-02-02 A | 2004-02-17 A | 1 | 100% |  | 2004-02-02 | 2004-02-17 | 10d |  |  | finish no earlier than 2004-02-17 | 김혜영 | 100h | 100h | 380,000 | 380,000 | 380,000 |
| 4 | 2.2 | 요구사항 정의서 |  | 3d | 2004-02-17 A | 2004-02-20 A | 3 | 100% |  | 2004-02-17 | 2004-02-20 | 3d |  |  | finish no earlier than 2004-02-20 | 김혜영; 김기영 | 60h | 60h | 234,000 | 234,000 | 234,000 |
| 5 | 3 | **기초 설계** |  | 23d | 2004-02-18 A | 2004-03-26 |  | 43% | 13d | 2004-02-18 | 2004-03-26 | 23d | 169.2d |  |  |  | 460h | 200h | 1,794,000 | 1,794,000 | 780,000 |
| 6 | 3.1 | 기초 설계 |  | 1mo | 2004-02-18 A | 2004-03-22 | 3 | 50% | 0.5mo | 2004-02-18 | 2004-03-22 | 1mo | 42.2d | 0d |  | 김혜영; 김기영 | 400h | 200h | 1,560,000 | 1,560,000 | 780,000 |
| 7 | 3.2 | 기초 설계서 검토 |  | 3d | 2004-03-22 | 2004-03-26 | 6 |  |  | 2004-03-22 | 2004-03-26 | 3d | 169.2d |  |  | 김혜영; 김기영 | 60h |  | 234,000 | 234,000 |  |
| 8 | 4 | **개발** |  | 120d | 2004-03-22 | 2004-10-07 |  |  |  | 2004-03-22 | 2004-10-07 | 120d | 42.2d |  |  |  | 3900h |  | 17,160,000 | 17,160,000 |  |
| 9 | 4.1 | 프로토타입1 작성 |  | 6w | 2004-03-22 | 2004-05-11 | 6 |  |  | 2004-03-22 | 2004-05-11 | 6w | 42.2d | 0d |  | 김기영; 이가람; 이석훈; 전수진 | 1200h |  | 5,340,000 | 5,340,000 |  |
| 10 | 4.2 | 프로토타입 검토 |  | 3d | 2004-05-11 | 2004-05-17 | 9 |  |  | 2004-05-11 | 2004-05-17 | 3d | 42.2d | 0d |  | 김혜영; 김기영 | 60h |  | 234,000 | 234,000 |  |
| 11 | 4.3 | 프로토타입2 작성 |  | 6w | 2004-05-17 | 2004-07-05 | 10 |  |  | 2004-05-17 | 2004-07-05 | 6w | 42.2d | 0d |  | 김기영; 이가람; 이석훈; 전수진 | 1200h |  | 5,340,000 | 5,340,000 |  |
| 12 | 4.4 | 프로토타입 검토 |  | 3d | 2004-07-05 | 2004-07-09 | 11 |  |  | 2004-07-05 | 2004-07-09 | 3d | 42.2d | 0d |  | 김혜영; 김기영 | 60h |  | 234,000 | 234,000 |  |
| 13 | 4.5 | 수정 및 보완 |  | 3w | 2004-07-09 | 2004-08-04 | 12 |  |  | 2004-07-09 | 2004-08-04 | 3w | 42.2d | 0d |  | 김기영; 이가람; 이석훈; 전수진 | 600h |  | 2,670,000 | 2,670,000 |  |
| 14 | 4.6 | 설계서 정리 |  | 3w | 2004-08-04 | 2004-08-30 | 13 |  |  | 2004-08-04 | 2004-08-30 | 3w | 42.2d | 0d |  | 이석훈; 전수진 | 300h |  | 1,470,000 | 1,470,000 |  |
| 15 | 4.7 | 통합 테스트 |  | 1mo | 2004-08-30 | 2004-09-30 | 14 |  |  | 2004-08-30 | 2004-09-30 | 1mo | 42.2d | 0d |  | 김혜영; 김기영 | 400h |  | 1,560,000 | 1,560,000 |  |
| 16 | 4.8 | 통합 테스트 수정 |  | 4d | 2004-10-01 | 2004-10-07 | 15 |  |  | 2004-10-01 | 2004-10-07 | 4d | 42.2d | 0d |  | 김혜영; 김기영 | 80h |  | 312,000 | 312,000 |  |
| 17 | 5 | **검수** |  | 52.2d | 2004-10-07 | 2005-01-03 |  |  |  | 2004-10-07 | 2005-01-03 | 52.2d | 0d |  |  |  | 600h |  | 2,494,000 | 2,494,000 |  |
| 18 | 5.1 | 데이터 이행 |  | 2w | 2004-10-07 | 2004-10-25 | 16 |  |  | 2004-10-07 | 2004-10-25 | 2w | 42.2d |  |  | 이석훈 | 100h |  | 500,000 | 500,000 |  |
| 19 | 5.2 | 운영 교육 |  | 1w | 2004-12-01 | 2004-12-08 |  |  |  | 2004-12-01 | 2004-12-08 | 1w | 15d |  |  | 전수진 | 50h |  | 240,000 | 240,000 |  |
| 20 | 5.3 | 검수 |  | 1mo | 2004-12-01 | 2005-01-03 |  |  |  | 2004-12-01 | 2005-01-03 | 1mo | 0d |  |  | 김혜영; 김기영 | 400h |  | 1,560,000 | 1,560,000 |  |
| 21 | 5.4 | 최종확인 |  | 2d | 2004-12-01 | 2004-12-03 |  |  |  | 2004-12-01 | 2004-12-03 | 2d | 18d |  |  | 김혜영; 김기영 | 40h |  | 156,000 | 156,000 |  |
| 22 | 5.5 | 공식 오픈 |  | 1d | 2004-12-01 | 2004-12-02 |  |  |  | 2004-12-01 | 2004-12-02 | 1d | 19d |  |  | 김혜영 | 10h |  | 38,000 | 38,000 |  |
